Schedule from GanttProject, 2025-10-02 to 2026-01-16.

## Calendars

- Project calendar: Mon-Fri working; Sat-Sun off.

## Schedule

| ID | Task | Type | Duration | Start | Finish |
| --- | --- | --- | --- | --- | --- |
| 1 | Anforderungen finalisieren |  | 6d | 2025-10-02 | 2025-10-09 |
| 2 | Befüllung der Einkaufsliste |  | 5d | 2025-10-03 | 2025-10-09 |
| 3 | CAD-Modelle erstellen |  | 10d | 2025-10-10 | 2025-10-23 |
| 4 | Platinen für Hauptplatine und Steckerplatine entwickeln |  | 5d | 2025-10-17 | 2025-10-23 |
| 5 | Platinen und Komponenten bestellen |  | 5d | 2025-10-24 | 2025-10-30 |
| 6 | Test 3D-Druck der Gehäuseteile |  | 5d | 2025-10-24 | 2025-10-30 |
| 7 | Mechanischer und elektrischer Aufbau des Projekts |  | 5d | 2025-10-31 | 2025-11-06 |
| 8 | Test-Software entwickeln um Komponenten zu testen |  | 5d | 2025-11-07 | 2025-11-13 |
| 9 | IR-Abstandssensor Simulink Code entwickeln |  | 10d | 2025-11-14 | 2025-11-27 |
| 10 | LCD Simulink Code entwickeln |  | 10d | 2025-11-14 | 2025-11-27 |
| 11 | Drehgeber Simulink Code entwickeln |  | 10d | 2025-11-14 | 2025-11-27 |
| 12 | Allgemeines Simulink Modell entwickeln |  | 10d | 2025-11-28 | 2025-12-11 |
| 13 | Zwischenstand anhand des Wiki-Artikels mit Betreuer besprechen, Bewertungsschema maßschneidern | milestone | 0d | 2025-11-28 | 2025-11-28 |
| 14 | Test des Simulink Modells |  | 10d | 2025-12-12 | 2025-12-25 |
| 15 | Anpassungen der Software oder Hardware |  | 12d | 2025-12-26 | 2026-01-12 |
| 16 | Dokumentation im Wiki und SVN |  | 73d | 2025-10-02 | 2026-01-12 |
| 17 | Abgabe im Wiki und SVN | milestone | 0d | 2026-01-12 | 2026-01-12 |
| 18 | Projektmesse | milestone | 0d | 2026-01-16 | 2026-01-16 |
